# Exportprojekt

Schedule from GanttProject, 2013-07-01 to 2015-02-02, baseline: ew.
MKIK
Háromkerekű műanyag kismotorokkal a szlovák piacon szeretne megjelenni 2014. végéig / Cél: egy darab kizárólagos disztribútor felkutatása, megállapodás

## Calendars

- Project calendar: Mon-Fri working; Sat-Sun off.

## Resources

| Resource |
| --- |
| Kovács István |

## Schedule

| ID | WBS | Task | Type | Duration | Start | Finish | Complete | Baseline start | Baseline finish | Baseline duration | Baseline 1 start | Baseline 1 finish | Resources |
| --- | --- | --- | --- | --- | --- | --- | --- | --- | --- | --- | --- | --- | --- |
| 1 | 1 | Exportprojekt KEZDETE | milestone | 0d | 2013-07-01 | 2013-07-01 |  |  |  |  | 2013-07-01 | 2013-07-01 |  |
| 2 | 2 | **Exportprojekt előkészítése** |  | 110d | 2013-07-01 | 2013-11-29 | 100% |  |  |  | 2013-07-01 | 2013-11-29 |  |
| 3 | 2.1 | A belső feltételek vizsgálata |  | 11d | 2013-07-01 | 2013-07-15 | 100% |  |  |  | 2013-07-01 | 2013-07-15 |  |
| 4 | 2.2 | A külső feltételek vizsgálata |  | 44d | 2013-07-16 | 2013-09-13 | 100% |  |  |  | 2013-07-16 | 2013-09-13 |  |
| 5 | 2.3 | Az exportstratégia kialakítása |  | 34d | 2013-09-16 | 2013-10-31 | 100% |  |  |  | 2013-09-16 | 2013-10-31 |  |
| 6 | 2.4 | Az exportterv összeállítása |  | 21d | 2013-11-01 | 2013-11-29 | 100% |  |  |  | 2013-11-01 | 2013-11-29 |  |
| 7 | 3 | **Marketingeszközök készítése** |  | 45d | 2013-12-02 | 2014-01-31 |  | 2013-11-15 | 2014-02-28 | 76d | 2013-12-02 | 2014-01-31 |  |
| 8 | 3.1 | **Angol nyelvű weboldal a pot. partnerek felé** |  | 45d | 2013-12-02 | 2014-01-31 |  |  |  |  | 2013-12-02 | 2014-01-31 |  |
| 9 | 3.1.1 | Koncepció kialakítása |  | 10d | 2013-12-02 | 2013-12-13 |  |  |  |  | 2013-12-02 | 2013-12-13 |  |
| 10 | 3.1.2 | Honlap struktúra kialakítása |  | 10d | 2013-12-16 | 2013-12-27 |  |  |  |  | 2013-12-16 | 2013-12-27 |  |
| 11 | 3.1.3 | Grafika, layout kialakítása |  | 15d | 2013-12-30 | 2014-01-17 |  |  |  |  | 2013-12-30 | 2014-01-17 |  |
| 12 | 3.1.4 | Szövegek megírása magyarul |  | 15d | 2013-12-30 | 2014-01-17 |  |  |  |  | 2013-12-30 | 2014-01-17 |  |
| 13 | 3.1.5 | Szövegek angolra fordítása |  | 10d | 2014-01-20 | 2014-01-31 |  |  |  |  | 2014-01-20 | 2014-01-31 |  |
| 14 | 3.1.6 | Programozás, sitebuilding |  | 15d | 2013-12-30 | 2014-01-17 |  |  |  |  | 2013-12-30 | 2014-01-17 |  |
| 15 | 3.1.7 | Honlap feltöltése |  | 10d | 2014-01-20 | 2014-01-31 |  |  |  |  | 2014-01-20 | 2014-01-31 |  |
| 16 | 3.2 | Angol ny. nyomtatott anyagok |  | 45d | 2013-12-02 | 2014-01-31 |  |  |  |  | 2013-12-02 | 2013-12-02 |  |
| 17 | 4 | **Partnerkeresés** |  | 172d | 2014-03-06 | 2014-10-31 |  | 2014-03-21 | 2014-03-21 | 1d | 2014-03-06 | 2014-10-31 |  |
| 18 | 4.1 | **Rendezvényeken részvétel** |  | 65d | 2014-04-17 | 2014-07-16 |  | 2014-03-21 | 2014-03-21 | 1d | 2014-04-17 | 2014-07-16 |  |
| 19 | 4.1.1 | Potenciális rendezvények (vásárok, kiállítások, üzletember-találkozók) kigyűjtése a köv. 1 évre |  | 3d | 2014-04-17 | 2014-04-21 |  |  |  |  | 2014-04-17 | 2014-04-21 |  |
| 20 | 4.1.2 | Részvétel a rendezvényeken |  | 62d | 2014-04-22 | 2014-07-16 |  |  |  |  | 2014-04-22 | 2014-07-16 |  |
| 21 | 4.1.3 | Adatok és névjegyek feldolgozása CRM-ben |  | 62d | 2014-04-17 | 2014-07-11 |  |  |  |  | 2014-04-17 | 2014-07-11 |  |
| 22 | 4.2 | Pot. partnerek keresése interneten |  | 62d | 2014-03-06 | 2014-05-30 |  |  |  |  | 2014-03-06 | 2014-05-30 | Kovács István |
| 23 | 4.3 | Partnerkereső szervezetekkel kapcs., pl. Kamara, EEN |  | 17d | 2014-03-07 | 2014-03-31 |  |  |  |  | 2014-03-07 | 2014-03-31 |  |
| 24 | 4.4 | Potenciális partnerek adatbázisa | milestone | 0d | 2014-06-02 | 2014-06-02 |  |  |  |  | 2014-06-02 | 2014-06-02 |  |
| 25 | 4.5 | Kapcsolatfelvétel a potenciális partnerekkel |  | 21d | 2014-06-02 | 2014-06-30 |  |  |  |  | 2014-06-02 | 2014-06-30 |  |
| 26 | 4.6 | Tárgyalások, kiutazások |  | 66d | 2014-07-01 | 2014-09-30 |  |  |  |  | 2014-07-01 | 2014-09-30 |  |
| 27 | 4.7 | Kizárólagos disztribútor partner megtalálása | milestone | 0d | 2014-10-01 | 2014-10-01 |  |  |  |  | 2014-10-01 | 2014-10-01 |  |
| 28 | 4.8 | Szerződéskötés |  | 23d | 2014-10-01 | 2014-10-31 |  |  |  |  | 2014-10-01 | 2014-10-31 |  |
| 29 | 5 | Operatív folyamatok előkészítése |  | 111d | 2014-06-02 | 2014-11-03 |  |  |  |  |  |  |  |
| 30 | 6 | Exportértékesítés kezdete | milestone | 0d | 2014-11-03 | 2014-11-03 |  |  |  |  | 2014-11-03 | 2014-11-03 |  |
| 31 | 7 | Első árbevétel beérkezése | milestone | 0d | 2015-02-02 | 2015-02-02 |  |  |  |  | 2015-02-02 | 2015-02-02 |  |
| 32 | 8 | Exportprojekt VÉGE | milestone | 0d | 2015-02-02 | 2015-02-02 |  |  |  |  | 2015-02-02 | 2015-02-02 |  |

Notes:
- 7: Célja: a külföldi partnerek megtalálása
